# VENI planning 2

Schedule from MS Project, 2006-07-03 to 2010-07-02.
NIKHEF

## Calendars

- Standard: Mon-Fri 08:00-12:00, 13:00-17:00; Sat-Sun off.

## Schedule

| ID | WBS | Task | Type | Duration | Start | Finish | Predecessors | Baseline start | Baseline finish | Baseline duration | Total slack | Free slack | Constraint |
| --- | --- | --- | --- | --- | --- | --- | --- | --- | --- | --- | --- | --- | --- |
| 1 | 1 | **Chasing the Higgs boson with a world wide trigger** |  | 1045d? | 2006-07-03 | 2010-07-02 |  |  |  |  | 0d |  |  |
| 2 | 1.1 | **Development of computing infrastructure** |  | 500d? | 2006-07-03 | 2008-05-30 |  | 2006-01-02 | 2007-11-09 | 485d? | 15d |  |  |
| 3 | 1.1.1 | **Connection to the event filter** |  | 500d? | 2006-07-03 | 2008-05-30 |  | 2006-01-02 | 2007-03-30 | 325d? | 15d |  |  |
| 4 | 1.1.1.1 | Investigate connection schemes |  | 85d? | 2006-07-03 | 2006-10-27 |  | 2006-01-02 | 2006-04-28 | 85d? | 15d | 0d | start no earlier than 2006-07-03 |
| 5 | 1.1.1.2 | Order equipment | milestone | 1d? | 2006-10-30 | 2006-10-30 | 4 | 2006-05-01 | 2006-05-01 | 1d? | 934d | 194d |  |
| 6 | 1.1.1.3 | **Testbed development** |  | 110d? | 2006-10-30 | 2007-03-30 |  | 2006-05-01 | 2006-09-29 | 110d? | 15d | 0d |  |
| 7 | 1.1.1.3.1 | Install testbed hardware |  | 60d? | 2006-10-30 | 2007-01-19 | 4 | 2006-05-01 | 2006-07-21 | 60d? | 15d | 0d |  |
| 8 | 1.1.1.3.2 | Test new equipment |  | 30d? | 2007-01-22 | 2007-03-02 | 7 | 2006-07-24 | 2006-09-01 | 30d? | 15d | 0d |  |
| 9 | 1.1.1.3.3 | Install grid software |  | 20d? | 2007-03-05 | 2007-03-30 | 8 | 2006-09-04 | 2006-09-29 | 20d? | 15d | 0d |  |
| 10 | 1.1.1.4 | **On-site deployment** |  | 305d? | 2007-04-02 | 2008-05-30 | 6 | 2006-10-02 | 2007-03-30 | 130d? | 85d |  |  |
| 11 | 1.1.1.4.1 | Coordinate with event filter group |  | 30d? | 2007-04-02 | 2007-05-11 |  | 2006-10-02 | 2006-11-10 | 30d? | 85d | 5d | start no earlier than 2007-02-11 |
| 12 | 1.1.1.4.2 | Install all dedicated hardware |  | 25d? | 2007-07-30 | 2007-08-31 | 11, 5 | 2007-02-26 | 2007-03-30 | 25d? | 740d |  | start no earlier than 2007-07-29 |
| 13 | 1.1.1.4.3 | Integrate with event filter |  | 155d? | 2007-05-21 | 2007-12-21 | 11 |  |  |  | 80d | 0d | start no earlier than 2007-05-20 |
| 14 | 1.1.1.4.4 | Testing and debugging |  | 115d? | 2007-12-24 | 2008-05-30 | 13 |  |  |  | 545d |  |  |
| 15 | 1.1.2 | **Connection to Amsterdam Tier-1** |  | 210d? | 2006-10-02 | 2007-07-20 |  | 2006-03-27 | 2007-01-12 | 210d? | 5d |  |  |
| 16 | 1.1.2.1 | Investigate connection schemes |  | 60d? | 2006-10-02 | 2007-04-27 |  | 2006-03-27 | 2006-10-20 | 60d? | 5d | 0d | start no earlier than 2006-10-01 |
| 17 | 1.1.2.2 | Write dedicated software for connection |  | 60d? | 2007-04-30 | 2007-07-20 | 16 | 2006-10-23 | 2007-01-12 | 60d? | 5d | 0d |  |
| 18 | 1.2 | **Simulation and integration** |  | 525d? | 2006-07-03 | 2008-07-04 |  | 2006-01-02 | 2007-11-09 | 485d? | 5d |  |  |
| 19 | 1.2.1 | Monte Carlo simulations |  | 115d? | 2006-07-03 | 2006-12-08 |  | 2006-01-02 | 2006-06-02 | 110d? | 5d | 0d | start no earlier than 2006-07-03 |
| 20 | 1.2.2 | Development of event filter add-on |  | 160d? | 2006-07-24 | 2007-03-02 |  | 2006-02-13 | 2006-09-22 | 160d? | 35d | 20d | start no earlier than 2006-07-23 |
| 21 | 1.2.3 | Install add-on on testbed |  | 70d? | 2007-04-02 | 2007-07-06 | 9, 20 | 2006-10-02 | 2007-01-05 | 70d? | 15d | 10d | start no earlier than 2007-03-18 |
| 22 | 1.2.4 | Integrate testbed with high-speed link |  | 110d? | 2007-07-23 | 2007-12-21 | 21, 17 | 2007-01-15 | 2007-06-15 | 110d? | 5d | 0d | start no earlier than 2007-07-15 |
| 23 | 1.2.5 | Development of real-time analysis algorithms |  | 270d? | 2006-12-11 | 2007-12-21 | 19 | 2006-06-05 | 2007-06-15 | 270d? | 5d | 0d |  |
| 24 | 1.2.6 | Deployment and debugging of algorithms |  | 115d? | 2007-12-24 | 2008-05-30 | 23, 22 | 2007-06-18 | 2007-11-09 | 105d? | 5d | 0d | start no earlier than 2007-12-16 |
| 25 | 1.2.7 | Release algorithms for experiment | milestone | 1d? | 2008-06-02 | 2008-06-02 | 24 |  |  |  | 5d | 0d |  |
| 26 | 1.2.8 | Write-up |  | 24d? | 2008-06-03 | 2008-07-04 | 25 |  |  |  | 5d | 0d |  |

| ID | WBS | Task | Duration | Start | Finish | Predecessors | Total slack | Free slack | Constraint |
| --- | --- | --- | --- | --- | --- | --- | --- | --- | --- |
| 27 | 1.3 | **Analysis** | 660d? | 2007-12-24 | 2010-07-02 |  | 0d |  |  |
| 28 | 1.3.1 | Test basic functionality of distributed trigger | 65d? | 2007-12-24 | 2008-03-21 | 13 | 80d | 75d | start no earlier than 2007-12-23 |
| 29 | 1.3.2 | Processing of ttbar events | 515d? | 2008-07-14 | 2010-07-02 | 28, 26 | 0d |  | finish no earlier than 2010-07-02 |
| 30 | 1.3.3 | Analyse standard ttbar channels | 230d? | 2008-03-31 | 2009-02-13 |  | 0d |  | start no earlier than 2008-03-30 |
| 31 | 1.3.4 | Understand top mass and background spectrum | 130d? | 2008-08-18 | 2009-02-13 |  | 0d |  | start no earlier than 2008-08-17 |
| 32 | 1.3.5 | Improve simulations and analysis | 410d? | 2008-05-05 | 2009-11-27 |  | 25d | 0d | start no earlier than 2008-05-04 |
| 33 | 1.3.6 | Implement semi/fully hadronic ttbar Higgs analysis | 295d? | 2009-02-16 | 2010-04-02 | 31, 30 | 0d |  |  |
| 34 | 1.3.7 | Integrate results with other ATLAS Higgs analysis | 130d? | 2009-11-30 | 2010-05-28 | 32 | 25d |  | start no earlier than 2009-03-15 |
| 35 | 1.3.8 | Write-up | 65d? | 2010-04-05 | 2010-07-02 | 33 | 0d |  | start no earlier than 2009-08-09 |
